# Software Development

Schedule from MS Project, 2018-02-26 to 2018-07-25, A marks actual dates.

## Calendars

- Standard: Mon-Fri 08:00-12:00, 13:00-17:00; Sat-Sun off.

## Resources

| Resource |
| --- |
| Management |
| Project Manager |
| Analyst |
| Developer |
| Testers |
| Trainers |
| Technical Communicators |
| Deployment Team |

## Schedule

| ID | WBS | Task | Type | Duration | Start | Finish | Predecessors | Complete | Remaining | Total slack | Free slack | Resources | Work | Actual work |
| --- | --- | --- | --- | --- | --- | --- | --- | --- | --- | --- | --- | --- | --- | --- |
| 1 | 1 | **Scope** |  | 3.5d | 2018-02-26 | 2018-03-01 |  |  |  | 1d |  |  | 28h |  |
| 2 | 1.1 | Determine project scope |  | 4h | 2018-02-26 | 2018-02-26 |  |  |  | 1d | 0d | Management | 4h |  |
| 3 | 1.2 | Secure project sponsorship |  | 1d | 2018-02-26 | 2018-02-27 | 2 |  |  | 1d | 0d | Management | 8h |  |
| 4 | 1.3 | Define preliminary resources |  | 1d | 2018-02-27 | 2018-02-28 | 3 |  |  | 1d | 0d | Project Manager | 8h |  |
| 5 | 1.4 | Secure core resources |  | 1d | 2018-02-28 | 2018-03-01 | 4 |  |  | 1d | 0d | Project Manager | 8h |  |
| 6 | 1.5 | Scope complete | milestone | 0d | 2018-03-01 | 2018-03-01 | 5 |  |  | 1d | 0d |  |  |  |
| 7 | 2 | **Analysis/Software Requirements** |  | 14d | 2018-03-01 | 2018-03-21 |  |  |  | 1d |  |  | 120h |  |
| 8 | 2.1 | Conduct needs analysis |  | 5d | 2018-03-01 | 2018-03-08 | 6 |  |  | 1d | 0d | Analyst | 40h |  |
| 9 | 2.2 | Draft preliminary software specifications |  | 3d | 2018-03-08 | 2018-03-13 | 8 |  |  | 1d | 0d | Analyst | 24h |  |
| 10 | 2.3 | Develop preliminary budget |  | 2d | 2018-03-13 | 2018-03-15 | 9 |  |  | 1d | 0d | Project Manager | 16h |  |
| 11 | 2.4 | Review software specifications/budget with team |  | 4h | 2018-03-15 | 2018-03-15 | 10 |  |  | 1d | 0d | Project Manager; Analyst | 8h |  |
| 12 | 2.5 | Incorporate feedback on software specifications |  | 1d | 2018-03-16 | 2018-03-16 | 11 |  |  | 1d | 0d | Analyst | 8h |  |
| 13 | 2.6 | Develop delivery timeline |  | 1d | 2018-03-19 | 2018-03-19 | 12 |  |  | 1d | 0d | Project Manager | 8h |  |
| 14 | 2.7 | Obtain approvals to proceed (concept, timeline, budget) |  | 4h | 2018-03-20 | 2018-03-20 | 13 |  |  | 1d | 0d | Management; Project Manager | 8h |  |
| 15 | 2.8 | Secure required resources |  | 1d | 2018-03-20 | 2018-03-21 | 14 |  |  | 1d | 0d | Project Manager | 8h |  |
| 16 | 2.9 | Analysis complete | milestone | 0d | 2018-03-21 | 2018-03-21 | 15 |  |  | 1d | 0d |  |  |  |
| 17 | 3 | **Design** |  | 26.5d | 2018-03-21 A | 2018-04-26 |  | 16% | 22.19d | 0d |  |  | 144h | 28h |
| 18 | 3.1 | Review preliminary software specifications |  | 2d | 2018-03-21 A | 2018-03-23 | 16 | 50% | 1d | 2.5d | 0d | Analyst | 16h | 8h |
| 19 | 3.2 | Develop functional specifications |  | 8d | 2018-03-23 A | 2018-04-11 | 18 | 31% | 5.5d | 0d |  | Analyst | 64h | 20h |
| 20 | 3.3 | Develop prototype based on functional specifications |  | 4d | 2018-04-11 | 2018-04-17 | 19 |  |  | 0d |  | Analyst | 32h |  |
| 21 | 3.4 | This is a test task |  | 4d | 2018-04-17 | 2018-04-23 | 20 |  |  | 0d |  |  |  |  |
| 22 | 3.5 | Review functional specifications |  | 2d | 2018-04-23 | 2018-04-25 | 21 |  |  | 0d |  | Management | 16h |  |
| 23 | 3.6 | Incorporate feedback into functional specifications |  | 1d | 2018-04-25 | 2018-04-26 | 22 |  |  | 0d |  | Management | 8h |  |
| 24 | 3.7 | Obtain approval to proceed |  | 4h | 2018-04-26 | 2018-04-26 | 23 |  |  | 0d |  | Management; Project Manager | 8h |  |
| 25 | 3.8 | Design complete | milestone | 0d | 2018-04-26 | 2018-04-26 | 24 |  |  | 0d |  |  |  |  |

| ID | WBS | Task | Type | Duration | Start | Finish | Predecessors | Total slack | Free slack | Resources | Work |
| --- | --- | --- | --- | --- | --- | --- | --- | --- | --- | --- | --- |
| 26 | 4 | **Development** |  | 21.75d | 2018-04-27 | 2018-05-28 |  | 0d |  |  | 264h |
| 27 | 4.1 | Review functional specifications |  | 1d | 2018-04-27 | 2018-04-27 | 25 | 0d |  | Developer | 8h |
| 28 | 4.2 | Identify modular/tiered design parameters |  | 1d | 2018-04-30 | 2018-04-30 | 27 | 0d |  | Developer | 8h |
| 29 | 4.3 | Assign development staff |  | 1d | 2018-05-01 | 2018-05-01 | 28 | 0d |  | Developer | 8h |
| 30 | 4.4 | Develop code |  | 15d | 2018-05-02 | 2018-05-22 | 29 | 0d |  | Developer | 120h |
| 31 | 4.5 | Developer testing (primary debugging) |  | 15d | 2018-05-07 | 2018-05-28 | 30FS-7.5% | 0d |  | Developer | 120h |
| 32 | 4.6 | Development complete | milestone | 0d | 2018-05-28 | 2018-05-28 | 31 | 0d |  |  |  |
| 33 | 5 | **Testing** |  | 48.75d | 2018-04-27 | 2018-07-04 |  | 15d |  |  | 280h |
| 34 | 5.1 | Develop unit test plans using product specifications |  | 4d | 2018-04-27 | 2018-05-02 | 25 | 17.75d |  | Testers | 32h |
| 35 | 5.2 | Develop integration test plans using product specifications |  | 4d | 2018-04-27 | 2018-05-02 | 25 | 59.75d |  | Testers | 32h |
| 36 | 5.3 | **Unit Testing** |  | 15d | 2018-05-28 | 2018-06-18 |  | 0d |  |  | 120h |
| 37 | 5.3.1 | Review modular code |  | 5d | 2018-05-28 | 2018-06-04 | 34, 32 | 0d |  | Testers | 40h |
| 38 | 5.3.2 | Test component modules to product specifications |  | 2d | 2018-06-04 | 2018-06-06 | 32, 37 | 0d |  | Testers | 16h |
| 39 | 5.3.3 | Identify anomalies to product specifications |  | 3d | 2018-06-06 | 2018-06-11 | 38 | 0d |  | Testers | 24h |
| 40 | 5.3.4 | Modify code |  | 3d | 2018-06-11 | 2018-06-14 | 39 | 0d |  | Testers | 24h |
| 41 | 5.3.5 | Re-test modified code |  | 2d | 2018-06-14 | 2018-06-18 | 40 | 0d |  | Testers | 16h |
| 42 | 5.3.6 | Unit testing complete | milestone | 0d | 2018-06-18 | 2018-06-18 | 41 | 0d |  |  |  |
| 43 | 5.4 | **Integration Testing** |  | 12d | 2018-06-18 | 2018-07-04 |  | 0d |  |  | 96h |
| 44 | 5.4.1 | Test module integration |  | 5d | 2018-06-18 | 2018-06-25 | 42 | 0d |  | Testers | 40h |
| 45 | 5.4.2 | Identify anomalies to specifications |  | 2d | 2018-06-25 | 2018-06-27 | 44 | 0d |  | Testers | 16h |
| 46 | 5.4.3 | Modify code |  | 3d | 2018-06-27 | 2018-07-02 | 45 | 0d |  | Testers | 24h |
| 47 | 5.4.4 | Re-test modified code |  | 2d | 2018-07-02 | 2018-07-04 | 46 | 0d |  | Testers | 16h |
| 48 | 5.4.5 | Integration testing complete | milestone | 0d | 2018-07-04 | 2018-07-04 | 47 | 0d |  |  |  |
| 49 | 6 | **Training** |  | 45.75d | 2018-04-27 | 2018-06-29 |  | 3d |  |  | 256h |
| 50 | 6.1 | Develop training specifications for end users |  | 3d | 2018-04-27 | 2018-05-01 | 25 | 21.75d | 18.75d | Trainers | 24h |
| 51 | 6.2 | Develop training specifications for helpdesk support staff |  | 3d | 2018-04-27 | 2018-05-01 | 25 | 21.75d | 18.75d | Trainers | 24h |
| 52 | 6.3 | Identify training delivery methodology (computer based training, classroom, etc.) |  | 2d | 2018-04-27 | 2018-04-30 | 25 | 22.75d | 19.75d | Trainers | 16h |
| 53 | 6.4 | Develop training materials |  | 3w | 2018-05-28 | 2018-06-18 | 50, 32, 51, 52 | 3d | 0d | Trainers | 120h |
| 54 | 6.5 | Conduct training usability study |  | 4d | 2018-06-18 | 2018-06-22 | 53 | 3d | 0d | Trainers | 32h |
| 55 | 6.6 | Finalize training materials |  | 3d | 2018-06-22 | 2018-06-27 | 54 | 3d | 0d | Trainers | 24h |
| 56 | 6.7 | Develop training delivery mechanism |  | 2d | 2018-06-27 | 2018-06-29 | 55 | 3d | 0d | Trainers | 16h |
| 57 | 6.8 | Training materials complete | milestone | 0d | 2018-06-29 | 2018-06-29 | 56 | 3d |  |  |  |

| ID | WBS | Task | Type | Duration | Start | Finish | Predecessors | Total slack | Free slack | Resources | Work |
| --- | --- | --- | --- | --- | --- | --- | --- | --- | --- | --- | --- |
| 58 | 7 | **Documentation** |  | 30.5d | 2018-04-27 | 2018-06-08 |  | 18.25d |  |  | 336h |
| 59 | 7.1 | Develop Help specification |  | 1d | 2018-04-27 | 2018-04-27 | 25 | 27.75d | 9.5d | Technical Communicators | 8h |
| 60 | 7.2 | Develop Help system |  | 3w | 2018-05-11 | 2018-06-01 | 59, 30FS-5% | 18.25d | 0d | Technical Communicators | 120h |
| 61 | 7.3 | Review Help documentation |  | 3d | 2018-06-01 | 2018-06-06 | 60 | 18.25d | 0d | Technical Communicators | 24h |
| 62 | 7.4 | Incorporate Help documentation feedback |  | 2d | 2018-06-06 | 2018-06-08 | 61 | 18.25d | 0d | Technical Communicators | 16h |
| 63 | 7.5 | Develop user manuals specifications |  | 2d | 2018-04-27 | 2018-04-30 | 25 | 27.75d | 8.5d | Technical Communicators | 16h |
| 64 | 7.6 | Develop user manuals |  | 3w | 2018-05-11 | 2018-06-01 | 63, 30FS-5% | 19.25d | 0d | Technical Communicators | 120h |
| 65 | 7.7 | Review all user documentation |  | 2d | 2018-06-01 | 2018-06-05 | 64 | 19.25d | 0d | Technical Communicators | 16h |
| 66 | 7.8 | Incorporate user documentation feedback |  | 2d | 2018-06-05 | 2018-06-07 | 65 | 19.25d | 1d | Technical Communicators | 16h |
| 67 | 7.9 | Documentation complete | milestone | 0d | 2018-06-08 | 2018-06-08 | 66, 62 | 18.25d |  |  |  |
| 68 | 8 | **Pilot** |  | 82.25d | 2018-03-21 | 2018-07-13 |  | 0d |  |  | 64h |
| 69 | 8.1 | Identify test group |  | 1d | 2018-03-21 | 2018-03-22 | 16 | 73.25d | 0d | Project Manager | 8h |
| 70 | 8.2 | Develop software delivery mechanism |  | 1d | 2018-03-22 | 2018-03-23 | 69 | 73.25d |  |  |  |
| 71 | 8.3 | Install/deploy software |  | 1d | 2018-07-04 | 2018-07-05 | 48, 70, 67, 57 | 0d |  | Deployment Team | 8h |
| 72 | 8.4 | Obtain user feedback |  | 1w | 2018-07-05 | 2018-07-12 | 71 | 0d |  | Deployment Team | 40h |
| 73 | 8.5 | Evaluate testing information |  | 1d | 2018-07-12 | 2018-07-13 | 72 | 0d |  | Deployment Team | 8h |
| 74 | 8.6 | Pilot complete | milestone | 0d | 2018-07-13 | 2018-07-13 | 73 | 0d |  |  |  |
| 75 | 9 | **Deployment** |  | 5d | 2018-07-13 | 2018-07-20 |  | 0d |  |  | 40h |
| 76 | 9.1 | Determine final deployment strategy |  | 1d | 2018-07-13 | 2018-07-16 | 74 | 0d |  | Deployment Team | 8h |
| 77 | 9.2 | Develop deployment methodology |  | 1d | 2018-07-16 | 2018-07-17 | 76 | 0d |  | Deployment Team | 8h |
| 78 | 9.3 | Secure deployment resources |  | 1d | 2018-07-17 | 2018-07-18 | 77 | 0d |  | Deployment Team | 8h |
| 79 | 9.4 | Train support staff |  | 1d | 2018-07-18 | 2018-07-19 | 78 | 0d |  | Deployment Team | 8h |
| 80 | 9.5 | Deploy software |  | 1d | 2018-07-19 | 2018-07-20 | 79 | 0d |  | Deployment Team | 8h |
| 81 | 9.6 | Deployment complete | milestone | 0d | 2018-07-20 | 2018-07-20 | 80 | 0d |  |  |  |

| ID | WBS | Task | Type | Duration | Start | Finish | Predecessors | Total slack | Resources | Work |
| --- | --- | --- | --- | --- | --- | --- | --- | --- | --- | --- |
| 82 | 10 | **Post Implementation Review** |  | 3d | 2018-07-20 | 2018-07-25 |  | 0d |  | 24h |
| 83 | 10.1 | Document lessons learned |  | 1d | 2018-07-20 | 2018-07-23 | 81 | 0d | Project Manager | 8h |
| 84 | 10.2 | Distribute to team members |  | 1d | 2018-07-23 | 2018-07-24 | 83 | 0d | Project Manager | 8h |
| 85 | 10.3 | Create software maintenance team |  | 1d | 2018-07-24 | 2018-07-25 | 84 | 0d | Project Manager | 8h |
| 86 | 10.4 | Post implementation review complete | milestone | 0d | 2018-07-25 | 2018-07-25 | 85 | 0d |  |  |
| 87 | 11 | Software development template complete | milestone | 0d | 2018-07-25 | 2018-07-25 | 86 | 0d |  |  |
